# Kare A - rebelans 23.08.05

Schedule from MS Project, 2005-06-27 to 2006-07-26, A marks actual dates.
Energoplan

## Calendars

- Standard: Mon-Sun 08:00-12:00, 13:00-17:00.

## Resources

| Resource |
| --- |
| 3.600 |
| 3300 |
| 3100 |
| 2900 |
| 3800 |
| 3900 |
| 3700 |
| 3500 |
| 2800 |
| 2550 |
| 2300 |
| 2100 |

## Schedule

| ID | WBS | Task | Duration | Start | Finish | Complete | Remaining | Baseline start | Baseline finish | Baseline duration | Total slack | Constraint | Resources | Work | Actual work |
| --- | --- | --- | --- | --- | --- | --- | --- | --- | --- | --- | --- | --- | --- | --- | --- |
| 1 | 1 | **Poslovno upravni kulturni objekt - KARE´A´** | 394d | 2005-06-27 A | 2006-07-26 |  | 392.85d | 2005-06-27 | 2006-07-26 | 394d | 0d |  |  | 920h | 64h |
| 2 | 1.1 | Priprava gradbišča | 10d | 2005-06-27 | 2005-07-06 |  |  | 2005-06-27 | 2005-07-06 | 10d | 384d | start no earlier than 2005-06-27 |  |  |  |
| 3 | 1.2 | Izdelava načrta monitoringa | 15d | 2005-06-27 | 2005-07-11 |  |  | 2005-06-27 | 2005-07-11 | 15d | 379d | start no earlier than 2005-06-27 |  |  |  |
| 4 | 1.3 | Izvajanje meritev po načrtu monitoringa | 350d | 2005-07-11 | 2006-06-25 |  |  | 2005-07-11 | 2006-06-25 | 350d | 30d | start no earlier than 2005-07-11 |  |  |  |
| 5 | 1.4 | **I FAZA** | 266d | 2005-07-05 A | 2006-03-27 |  | 264.8d | 2005-07-05 | 2006-03-27 | 266d | 120d |  |  | 920h | 64h |
| 6 | 1.4.1 | **Gradbena dela** | 201d | 2005-07-05 A | 2006-01-21 | 1% | 199.59d | 2005-07-05 | 2006-01-21 | 201d | 185d |  |  | 920h | 64h |
| 7 | 1.4.1.1 | **IZKOP in ZAŠČITA GRADBENE JAME** | 81d | 2005-07-05 A | 2005-09-23 | 3% | 78.94d | 2005-07-05 | 2005-09-23 | 81d | 305d |  |  | 920h | 64h |
| 8 | 1.4.1.1.1 | Izkop do dna(3m) I. grede A-C osi 1-7 - cca 70m' | 2d | 2005-07-05 | 2005-07-06 |  |  | 2005-07-05 | 2005-07-06 | 2d | 384d | start no earlier than 2005-07-05 | 3.600 | 16h |  |
| 9 | 1.4.1.1.2 | Torkretiranje brežine z izdelavo grede | 7d | 2005-07-06 | 2005-07-12 |  |  | 2005-07-06 | 2005-07-12 | 7d | 378d | start no earlier than 2005-07-06 |  |  |  |
| 10 | 1.4.1.1.3 | Sidranje grede I. Nivoja (18kom) | 3d | 2005-07-07 | 2005-07-09 |  |  | 2005-07-07 | 2005-07-09 | 3d | 381d | start no earlier than 2005-07-07 |  |  |  |
| 11 | 1.4.1.1.4 | Izkop do dna(5,5m) III. grede A-C osi 1-7 | 6d | 2005-07-12 | 2005-07-17 |  |  | 2005-07-12 | 2005-07-14 | 3d | 373d | start no earlier than 2005-07-12 | 3300 | 48h |  |
| 12 | 1.4.1.1.5 | Torkretiranje brežine z izdelavo grede | 8d | 2005-07-13 | 2005-07-20 |  |  | 2005-07-13 | 2005-07-17 | 5d | 370d | start no earlier than 2005-07-13 |  |  |  |
| 13 | 1.4.1.1.6 | Sidranje grede II. Nivoja (18kom) | 5d | 2005-07-13 | 2005-07-17 |  |  | 2005-07-13 | 2005-07-17 | 5d | 373d | start no earlier than 2005-07-13 |  |  |  |
| 14 | 1.4.1.1.7 | Izkop do dna(9m) IIII. grede A-C osi 1-7 | 8d | 2005-07-18 | 2005-07-25 |  |  | 2005-07-18 | 2005-07-21 | 4d | 365d | start no earlier than 2005-07-18 | 3100 | 64h |  |
| 15 | 1.4.1.1.8 | Torkretiranje brežine z izdelavo grede | 7d | 2005-07-19 | 2005-07-25 |  |  | 2005-07-19 | 2005-07-22 | 4d | 365d | start no earlier than 2005-07-19 |  |  |  |
| 16 | 1.4.1.1.9 | Sidranje grede III. Nivoja (18kom) | 7d | 2005-07-20 | 2005-07-26 |  |  | 2005-07-20 | 2005-07-24 | 5d | 364d | start no earlier than 2005-07-20 |  |  |  |
| 17 | 1.4.1.1.10 | Izkop jame do globine temeljev 11,90 metra | 22d | 2005-07-21 A | 2005-08-11 | 36% | 14d | 2005-07-22 | 2005-07-25 | 4d | 348d | finish no earlier than 2005-07-25 | 2900 | 176h | 64h |
| 18 | 1.4.1.1.11 | Izkop do dna(3m) I. grede od C-F osi 1-8 | 6d | 2005-07-26 | 2005-07-31 |  |  | 2005-07-26 | 2005-07-31 | 6d | 359d | start no earlier than 2005-07-26 | 3800 | 48h |  |
| 19 | 1.4.1.1.12 | Torkretiranje brežine z izdelavo grede | 11d | 2005-07-28 | 2005-08-07 |  |  | 2005-07-28 | 2005-08-04 | 8d | 352d | start no earlier than 2005-07-28 |  |  |  |
| 20 | 1.4.1.1.13 | Sidranje grede I. Nivoja (11kom) | 4d | 2005-07-28 | 2005-07-31 |  |  | 2005-07-28 | 2005-07-31 | 4d | 359d | start no earlier than 2005-07-28 |  |  |  |
| 21 | 1.4.1.1.14 | Izkop do dna(6m) II. grede od C-F osi 1-8 | 12d | 2005-08-04 | 2005-08-15 |  |  | 2005-08-04 | 2005-08-06 | 3d | 344d | start no earlier than 2005-08-04 | 3900 | 96h |  |
| 22 | 1.4.1.1.15 | Torkretiranje brežine z izdelavo grede | 8d | 2005-08-04 | 2005-08-11 |  |  | 2005-08-04 | 2005-08-09 | 6d | 348d | start no earlier than 2005-08-04 |  |  |  |
| 23 | 1.4.1.1.16 | Sidranje grede I. Nivoja (12kom) | 5d | 2005-08-05 | 2005-08-09 |  |  | 2005-08-05 | 2005-08-08 | 4d | 350d | start no earlier than 2005-08-05 |  |  |  |
| 24 | 1.4.1.1.17 | Izkop do dna(9) III. . grede od C-F osi 1-8 | 10d | 2005-08-11 | 2005-08-20 |  |  | 2005-08-11 | 2005-08-14 | 4d | 339d | start no earlier than 2005-08-11 | 3700 | 80h |  |
| 25 | 1.4.1.1.18 | Torkretiranje brežine z izdelavo grede | 9d | 2005-08-12 | 2005-08-20 |  |  | 2005-08-12 | 2005-08-18 | 7d | 339d | start no earlier than 2005-08-12 |  |  |  |
| 26 | 1.4.1.1.19 | Sidranje grede I. Nivoja (11kom) | 7d | 2005-08-13 | 2005-08-19 |  |  | 2005-08-13 | 2005-08-19 | 7d | 340d | start no earlier than 2005-08-13 |  |  |  |
| 27 | 1.4.1.1.20 | Izkop jame do globine temeljev 11,90 metra | 30d | 2005-08-15 | 2005-09-13 |  |  | 2005-08-15 | 2005-08-21 | 7d | 315d | start no earlier than 2005-08-15 | 3500 | 240h |  |
| 28 | 1.4.1.1.21 | Postavitev žerjava | 4d | 2005-09-06 | 2005-09-09 |  |  | 2005-08-22 | 2005-08-25 | 4d | 319d | start no earlier than 2005-09-06 |  |  |  |
| 29 | 1.4.1.1.22 | Izkop do dna(3m) I. grede od osi 7' do osi F | 4d | 2005-08-25 | 2005-08-28 |  |  | 2005-08-23 | 2005-08-26 | 4d | 331d | start no earlier than 2005-08-25 | 2800 | 32h |  |
| 30 | 1.4.1.1.23 | Torkretiranje brežine z izdelavo grede | 5d | 2005-08-27 | 2005-08-31 |  |  | 2005-08-25 | 2005-08-29 | 5d | 328d | start no earlier than 2005-08-27 |  |  |  |
| 31 | 1.4.1.1.24 | Sidranje grede I. Nivoja (21kom) | 5d | 2005-08-31 | 2005-09-04 |  |  | 2005-08-25 | 2005-08-29 | 5d | 324d | start no earlier than 2005-08-31 |  |  |  |
| 32 | 1.4.1.1.25 | Izkop do dna(3m) II. grede od osi 7' do osi F | 4d | 2005-09-04 | 2005-09-07 |  |  | 2005-08-30 | 2005-09-02 | 4d | 321d | start no earlier than 2005-09-04 | 2550 | 32h |  |
| 33 | 1.4.1.1.26 | Torkretiranje brežine z izdelavo grede | 7d | 2005-09-04 | 2005-09-10 |  |  | 2005-09-01 | 2005-09-07 | 7d | 318d | start no earlier than 2005-09-04 |  |  |  |
| 34 | 1.4.1.1.27 | Sidranje grede II. Nivoja (21kom) | 5d | 2005-09-04 | 2005-09-08 |  |  | 2005-09-01 | 2005-09-05 | 5d | 320d | start no earlier than 2005-09-04 |  |  |  |
| 35 | 1.4.1.1.28 | Izkop do dna(3m) III. grede od osi 7' do osi F | 5d | 2005-09-08 | 2005-09-12 |  |  | 2005-09-06 | 2005-09-10 | 5d | 316d | start no earlier than 2005-09-08 | 2300 | 40h |  |
| 36 | 1.4.1.1.29 | Torkretiranje brežine z izdelavo grede | 6d | 2005-09-09 | 2005-09-14 |  |  | 2005-09-07 | 2005-09-12 | 6d | 314d | start no earlier than 2005-09-09 |  |  |  |
| 37 | 1.4.1.1.30 | Sidranje grede III. Nivoja (21kom) | 6d | 2005-09-11 | 2005-09-16 |  |  | 2005-09-07 | 2005-09-12 | 6d | 312d | start no earlier than 2005-09-11 |  |  |  |
| 38 | 1.4.1.1.31 | Izkop do dna jame | 6d | 2005-09-10 | 2005-09-15 |  |  | 2005-09-10 | 2005-09-15 | 6d | 313d | start no earlier than 2005-09-10 | 2100 | 48h |  |
| 39 | 1.4.1.1.32 | Torketiranje bržin | 14d | 2005-09-03 | 2005-09-16 |  |  | 2005-09-03 | 2005-09-16 | 14d | 312d | start no earlier than 2005-09-03 |  |  |  |
| 40 | 1.4.1.1.33 | Izkop za točkovne in pasovne temelje garaže | 61d | 2005-07-22 | 2005-09-20 |  |  | 2005-07-22 | 2005-09-20 | 61d | 308d | finish no earlier than 2005-09-20 |  |  |  |
| 41 | 1.4.1.1.34 | Izkop temeljev pod stebri na brežini | 6d | 2005-09-18 | 2005-09-23 |  |  | 2005-09-18 | 2005-09-23 | 6d | 305d | finish no earlier than 2005-09-23 |  |  |  |

| ID | WBS | Task | Duration | Start | Finish | Baseline start | Baseline finish | Baseline duration | Total slack | Constraint |
| --- | --- | --- | --- | --- | --- | --- | --- | --- | --- | --- |
| 42 | 1.4.1.2 | **AB DELA** | 132d | 2005-08-22 | 2005-12-31 | 2005-07-25 | 2005-12-31 | 160d | 206d |  |
| 43 | 1.4.1.2.1 | **Od osi 1-5** | 61d | 2005-08-22 | 2005-10-21 | 2005-07-25 | 2005-10-21 | 89d | 277d |  |
| 44 | 1.4.1.2.1.1 | Temelji s podložnim betonom | 25d | 2005-09-03 | 2005-09-27 | 2005-07-25 | 2005-08-27 | 17d | 301d | start no earlier than 2005-09-03 |
| 45 | 1.4.1.2.1.2 | Izvedba HI pod stenami in stebri | 5d | 2005-08-22 | 2005-08-26 | 2005-08-22 | 2005-08-26 | 5d | 333d | start no earlier than 2005-08-22 |
| 46 | 1.4.1.2.1.3 | Zasip med temelji | 32d | 2005-09-08 | 2005-10-09 | 2005-07-30 | 2005-09-01 | 14d | 289d | start no earlier than 2005-09-08 |
| 47 | 1.4.1.2.1.4 | Talna plošča | 14d | 2005-09-13 | 2005-09-26 | 2005-08-03 | 2005-09-05 | 14d | 302d | start no earlier than 2005-09-13 |
| 48 | 1.4.1.2.1.5 | Stene in stebri III. kleti | 12d | 2005-09-19 | 2005-09-30 | 2005-08-27 | 2005-09-07 | 12d | 298d | start no earlier than 2005-09-19 |
| 49 | 1.4.1.2.1.6 | Plošča nad III. Kletjo | 12d | 2005-09-22 | 2005-10-03 | 2005-09-03 | 2005-09-14 | 12d | 295d | start no earlier than 2005-09-22 |
| 50 | 1.4.1.2.1.7 | stene in stebri II. Kleti | 12d | 2005-09-24 | 2005-10-05 | 2005-09-08 | 2005-09-19 | 12d | 293d | start no earlier than 2005-09-24 |
| 51 | 1.4.1.2.1.8 | Plošča nad II. Kletjo | 12d | 2005-09-27 | 2005-10-08 | 2005-09-15 | 2005-09-26 | 12d | 290d | start no earlier than 2005-09-27 |
| 52 | 1.4.1.2.1.9 | Stene in stebri I. Kleti | 12d | 2005-09-29 | 2005-10-10 | 2005-09-20 | 2005-10-01 | 12d | 288d | start no earlier than 2005-09-29 |
| 53 | 1.4.1.2.1.10 | Plošča nad I. Kletjo | 12d | 2005-10-02 | 2005-10-13 | 2005-09-27 | 2005-10-08 | 12d | 285d | start no earlier than 2005-10-02 |
| 54 | 1.4.1.2.1.11 | Izvedba vertikalne HI z zaščito | 12d | 2005-10-07 | 2005-10-18 | 2005-10-04 | 2005-10-15 | 12d | 280d | start no earlier than 2005-10-07 |
| 55 | 1.4.1.2.1.12 | Zasip za kletnimi zidovi | 27d | 2005-09-25 | 2005-10-21 | 2005-10-08 | 2005-10-21 | 14d | 277d | start no earlier than 2005-09-25 |
| 56 | 1.4.1.2.2 | **Od osi 5-10** | 86d | 2005-10-07 | 2005-12-31 | 2005-10-02 | 2005-12-31 | 91d | 206d |  |
| 57 | 1.4.1.2.2.1 | Temelji s podložnim betonom | 21d | 2005-10-07 | 2005-10-27 | 2005-10-02 | 2005-10-22 | 21d | 271d | start no earlier than 2005-10-07 |
| 58 | 1.4.1.2.2.2 | Izvedba HI pod stenami in stebri | 5d | 2005-10-24 | 2005-10-28 | 2005-10-21 | 2005-10-25 | 5d | 270d | start no earlier than 2005-10-24 |
| 59 | 1.4.1.2.2.3 | Zasip med temelji | 15d | 2005-10-16 | 2005-10-30 | 2005-10-08 | 2005-10-22 | 15d | 268d | start no earlier than 2005-10-16 |
| 60 | 1.4.1.2.2.4 | Podložni beton | 15d | 2005-10-18 | 2005-11-01 | 2005-10-10 | 2005-10-24 | 15d | 266d | start no earlier than 2005-10-18 |
| 61 | 1.4.1.2.2.5 | Talna plošča | 16d | 2005-10-22 | 2005-11-06 | 2005-10-12 | 2005-10-27 | 16d | 261d | start no earlier than 2005-10-22 |
| 62 | 1.4.1.2.2.6 | Stene in stebri III. kleti | 18d | 2005-10-23 | 2005-11-09 | 2005-10-12 | 2005-10-29 | 18d | 258d | start no earlier than 2005-10-23 |
| 63 | 1.4.1.2.2.7 | Plošča nad III. Kletjo | 18d | 2005-10-26 | 2005-11-12 | 2005-10-21 | 2005-11-07 | 18d | 255d | start no earlier than 2005-10-26 |
| 64 | 1.4.1.2.2.8 | stene in stebri II. Kleti | 18d | 2005-11-02 | 2005-11-19 | 2005-10-29 | 2005-11-15 | 18d | 248d | start no earlier than 2005-11-02 |
| 65 | 1.4.1.2.2.9 | Plošča nad II. Kletjo | 18d | 2005-11-11 | 2005-11-28 | 2005-11-08 | 2005-11-25 | 18d | 239d | start no earlier than 2005-11-11 |
| 66 | 1.4.1.2.2.10 | Stene in stebri I. Kleti | 18d | 2005-11-20 | 2005-12-07 | 2005-11-17 | 2005-12-04 | 18d | 230d | start no earlier than 2005-11-20 |
| 67 | 1.4.1.2.2.11 | Plošča nad I. Kletjo | 18d | 2005-11-26 | 2005-12-13 | 2005-11-26 | 2005-12-13 | 18d | 224d | start no earlier than 2005-11-26 |
| 68 | 1.4.1.2.2.12 | Izvedba vertikalne HI z zaščito | 14d | 2005-12-10 | 2005-12-23 | 2005-12-10 | 2005-12-23 | 14d | 214d | start no earlier than 2005-12-10 |
| 69 | 1.4.1.2.2.13 | Zasip za kletnimi zidovi | 20d | 2005-12-12 | 2005-12-31 | 2005-12-12 | 2005-12-31 | 20d | 206d | start no earlier than 2005-12-12 |

| ID | WBS | Task | Duration | Start | Finish | Baseline start | Baseline finish | Baseline duration | Total slack | Constraint |
| --- | --- | --- | --- | --- | --- | --- | --- | --- | --- | --- |
| 70 | 1.4.1.3 | **ZIDARSKA DELA** | 43d | 2005-12-10 | 2006-01-21 | 2005-12-10 | 2006-01-21 | 43d | 185d |  |
| 71 | 1.4.1.3.1 | Izvedba horizontalne HI | 14d | 2005-12-10 | 2005-12-23 | 2005-12-10 | 2005-12-23 | 14d | 214d | finish no earlier than 2005-12-23 |
| 72 | 1.4.1.3.2 | Pozidave s siporeks bloketi | 15d | 2005-12-10 | 2005-12-24 | 2005-12-10 | 2005-12-24 | 15d | 213d | start no earlier than 2005-12-10 |
| 73 | 1.4.1.3.3 | Izvedba litega asfalta | 14d | 2006-01-08 | 2006-01-21 | 2006-01-08 | 2006-01-21 | 14d | 185d | start no earlier than 2006-01-08 |
| 74 | 1.4.1.3.4 | Estrih | 14d | 2006-01-08 | 2006-01-21 | 2006-01-08 | 2006-01-21 | 14d | 185d | start no earlier than 2006-01-08 |
| 75 | 1.4.1.3.5 | Postavitev robnikov in ostala zaključna dela | 32d | 2005-12-15 | 2006-01-15 | 2005-12-15 | 2006-01-15 | 32d | 191d | start no earlier than 2005-12-15 |
| 76 | 1.4.1.4 | **KANALIZACIJA IN DRENAŽA** | 85d | 2005-10-01 | 2005-12-24 | 2005-10-01 | 2005-12-24 | 85d | 213d |  |
| 77 | 1.4.1.4.1 | Izvedba kanalizacije med temelji | 20d | 2005-10-01 | 2005-10-20 | 2005-10-01 | 2005-10-20 | 20d | 278d | finish no earlier than 2005-10-20 |
| 78 | 1.4.1.4.2 | Izvedba ostale kanalizacije | 24d | 2005-12-01 | 2005-12-24 | 2005-12-01 | 2005-12-24 | 24d | 213d | start no earlier than 2005-12-01 |
| 79 | 1.4.1.4.3 | Izvedba drenaže | 85d | 2005-10-01 | 2005-12-24 | 2005-10-01 | 2005-12-24 | 85d | 213d | start no earlier than 2005-10-01 |
| 80 | 1.4.1.4.4 | Izvedba ponikovalnice in jaškov | 31d | 2005-11-15 | 2005-12-15 | 2005-11-15 | 2005-12-15 | 31d | 222d | finish no earlier than 2005-12-15 |
| 81 | 1.4.1.5 | **ZASIP** | 82d | 2005-10-04 | 2005-12-24 | 2005-10-04 | 2005-12-24 | 82d | 213d |  |
| 82 | 1.4.1.5.1 | Izvedba vertikalne HI z zaščito osi 1-5 | 12d | 2005-10-04 | 2005-10-15 | 2005-10-04 | 2005-10-15 | 12d | 283d | start no earlier than 2005-10-04 |
| 83 | 1.4.1.5.2 | Zasip za zidovi osi 1-5 | 14d | 2005-10-08 | 2005-10-21 | 2005-10-08 | 2005-10-21 | 14d | 277d | start no earlier than 2005-10-08 |
| 84 | 1.4.1.5.3 | Izvedba vertikalne HI z zaščito osi 6-10 | 14d | 2005-12-07 | 2005-12-20 | 2005-12-07 | 2005-12-20 | 14d | 217d | finish no earlier than 2005-12-20 |
| 85 | 1.4.1.5.4 | Zasip za zidovi osi 6-10 | 13d | 2005-12-12 | 2005-12-24 | 2005-12-12 | 2005-12-24 | 13d | 213d | finish no earlier than 2005-12-24 |
| 86 | 1.4.1.6 | **ZAŠČITA OBJEKTA I.FAZE** | 93d | 2005-10-15 | 2006-01-15 | 2005-10-15 | 2006-01-15 | 93d | 191d |  |
| 87 | 1.4.1.6.1 | Izvedba horizontalne HI in plasti na plošči | 60d | 2005-10-15 | 2005-12-13 | 2005-10-15 | 2005-12-13 | 60d | 224d | start no earlier than 2005-10-15 |
| 88 | 1.4.1.6.2 | Izvedba parapetov, zaščite armature | 45d | 2005-12-02 | 2006-01-15 | 2005-12-02 | 2006-01-15 | 45d | 191d | finish no earlier than 2006-01-15 |
| 89 | 1.4.1.6.3 | Izvedba začasne strehe in zapora odprtin | 21d | 2005-12-20 | 2006-01-09 | 2005-12-20 | 2006-01-09 | 21d | 197d | start no earlier than 2005-12-20 |
| 90 | 1.4.2 | **Obrtniška dela** | 30d | 2006-01-05 | 2006-02-03 | 2006-01-05 | 2006-02-03 | 30d | 172d |  |
| 91 | 1.4.2.1 | POŽARNA VRATA | 21d | 2006-01-10 | 2006-01-30 | 2006-01-10 | 2006-01-30 | 21d | 176d | start no earlier than 2006-01-10 |
| 92 | 1.4.2.2 | DELA V ALUMINIJU | 7d | 2006-01-25 | 2006-01-31 | 2006-01-25 | 2006-01-31 | 7d | 175d | start no earlier than 2006-01-25 |
| 93 | 1.4.2.3 | KERAMIČARSKA DELA | 15d | 2006-01-05 | 2006-01-19 | 2006-01-05 | 2006-01-19 | 15d | 187d | start no earlier than 2006-01-05 |
| 94 | 1.4.2.4 | PLESKARSKA DELA | 10d | 2006-01-25 | 2006-02-03 | 2006-01-25 | 2006-02-03 | 10d | 172d | start no earlier than 2006-01-25 |
| 95 | 1.4.3 | Elektro inštalacije | 88d | 2005-12-01 | 2006-02-26 | 2005-12-01 | 2006-02-26 | 88d | 149d | finish no earlier than 2006-02-26 |
| 96 | 1.4.4 | Strojne inštalacije | 88d | 2005-12-01 | 2006-02-26 | 2005-12-01 | 2006-02-26 | 88d | 149d | finish no earlier than 2006-02-26 |

| ID | WBS | Task | Type | Duration | Start | Finish | Baseline start | Baseline finish | Baseline duration | Total slack | Constraint |
| --- | --- | --- | --- | --- | --- | --- | --- | --- | --- | --- | --- |
| 97 | 1.4.5 | **Zunanja ureditev** |  | 35d | 2006-01-15 | 2006-02-18 | 2006-01-15 | 2006-02-18 | 35d | 157d |  |
| 98 | 1.4.5.1 | Dostopna cesta v garažo |  | 35d | 2006-01-15 | 2006-02-18 | 2006-01-15 | 2006-02-18 | 35d | 157d | start no earlier than 2006-01-15 |
| 99 | 1.4.5.2 | Postajališče avtobusa |  | 25d | 2006-01-20 | 2006-02-13 | 2006-01-20 | 2006-02-13 | 25d | 162d | start no earlier than 2006-01-20 |
| 100 | 1.4.5.3 | Ograjni zid z gimnazijo |  | 14d | 2006-02-01 | 2006-02-14 | 2006-02-01 | 2006-02-14 | 14d | 161d | start no earlier than 2006-02-01 |
| 101 | 1.4.6 | **Priključki** |  | 83d | 2005-10-10 | 2005-12-31 | 2005-10-10 | 2005-12-31 | 83d | 206d |  |
| 102 | 1.4.6.1 | Plin |  | 83d | 2005-10-10 | 2005-12-31 | 2005-10-10 | 2005-12-31 | 83d | 206d | finish no earlier than 2005-12-31 |
| 103 | 1.4.6.2 | Priključek vode in nadomestni vodovod |  | 83d | 2005-10-10 | 2005-12-31 | 2005-10-10 | 2005-12-31 | 83d | 206d | finish no earlier than 2005-12-31 |
| 104 | 1.4.6.3 | Elektrika |  | 83d | 2005-10-10 | 2005-12-31 | 2005-10-10 | 2005-12-31 | 83d | 206d | finish no earlier than 2005-12-31 |
| 105 | 1.4.6.4 | TK priključek |  | 83d | 2005-10-10 | 2005-12-31 | 2005-10-10 | 2005-12-31 | 83d | 206d | finish no earlier than 2005-12-31 |
| 106 | 1.4.7 | Tehnični pregled | milestone | 0d | 2006-02-27 | 2006-02-27 | 2006-02-27 | 2006-02-27 | 0d | 148d | finish no earlier than 2006-02-27 |
| 107 | 1.4.8 | Uporabno dovoljenje | milestone | 0d | 2006-03-27 | 2006-03-27 | 2006-03-27 | 2006-03-27 | 0d | 120d | finish no earlier than 2006-03-27 |
| 108 | 1.5 | **II. FAZA** |  | 202d | 2006-01-05 | 2006-07-26 | 2006-01-05 | 2006-07-26 | 202d | 0d |  |
| 109 | 1.5.1 | **gradbena dela** |  | 167d | 2006-01-05 | 2006-06-20 | 2006-01-05 | 2006-06-20 | 167d | 35d |  |
| 110 | 1.5.1.1 | RUŠENJE ZAŠČITE I.FAZE |  | 14d | 2006-01-05 | 2006-01-18 | 2006-01-05 | 2006-01-18 | 14d | 188d | start no earlier than 2006-01-05 |
| 111 | 1.5.1.2 | **BETONSKO TESARSKA DELA** |  | 107d | 2006-01-09 | 2006-04-25 | 2006-01-09 | 2006-04-25 | 107d | 91d |  |
| 112 | 1.5.1.2.1 | Stene in stebri pritličja |  | 20d | 2006-01-09 | 2006-01-28 | 2006-01-09 | 2006-01-28 | 20d | 178d | start no earlier than 2006-01-09 |
| 113 | 1.5.1.2.2 | Plošča nad pritličjem |  | 21d | 2006-01-16 | 2006-02-05 | 2006-01-16 | 2006-02-05 | 21d | 170d | start no earlier than 2006-01-16 |
| 114 | 1.5.1.2.3 | Stene in stebri I. Nadstropja |  | 20d | 2006-01-29 | 2006-02-17 | 2006-01-29 | 2006-02-17 | 20d | 158d | start no earlier than 2006-01-29 |
| 115 | 1.5.1.2.4 | Plošča nad I. Nadstropjem |  | 21d | 2006-02-05 | 2006-02-25 | 2006-02-05 | 2006-02-25 | 21d | 150d | start no earlier than 2006-02-05 |
| 116 | 1.5.1.2.5 | Stene in stebri II. Nadstropja |  | 20d | 2006-02-18 | 2006-03-09 | 2006-02-18 | 2006-03-09 | 20d | 138d | start no earlier than 2006-02-18 |
| 117 | 1.5.1.2.6 | Plošča nad II. Nadstropjem |  | 21d | 2006-02-25 | 2006-03-17 | 2006-02-25 | 2006-03-17 | 21d | 130d | start no earlier than 2006-02-25 |
| 118 | 1.5.1.2.7 | Stene in stebri III. Nadstropja |  | 20d | 2006-03-10 | 2006-03-29 | 2006-03-10 | 2006-03-29 | 20d | 118d | start no earlier than 2006-03-10 |
| 119 | 1.5.1.2.8 | Plošča nad III. Nadstropjem |  | 21d | 2006-03-17 | 2006-04-06 | 2006-03-17 | 2006-04-06 | 21d | 110d | start no earlier than 2006-03-17 |
| 120 | 1.5.1.2.9 | Stene in stebri IV. Nadstropja |  | 20d | 2006-03-30 | 2006-04-18 | 2006-03-30 | 2006-04-18 | 20d | 98d | start no earlier than 2006-03-30 |
| 121 | 1.5.1.2.10 | Plošča nad IV. Nadstropjem |  | 20d | 2006-04-05 | 2006-04-24 | 2006-04-05 | 2006-04-24 | 20d | 92d | start no earlier than 2006-04-05 |
| 122 | 1.5.1.2.11 | Izvedba AB dela strehe |  | 7d | 2006-04-19 | 2006-04-25 | 2006-04-19 | 2006-04-25 | 7d | 91d | finish no earlier than 2006-04-25 |

| ID | WBS | Task | Type | Duration | Start | Finish | Baseline start | Baseline finish | Baseline duration | Total slack | Constraint |
| --- | --- | --- | --- | --- | --- | --- | --- | --- | --- | --- | --- |
| 123 | 1.5.1.3 | **ZIDARSKA DELA** |  | 45d | 2006-04-01 | 2006-05-15 | 2006-04-01 | 2006-05-15 | 45d | 71d |  |
| 124 | 1.5.1.3.1 | Zidanje zidov iz siporeksa |  | 40d | 2006-04-01 | 2006-05-10 | 2006-04-01 | 2006-05-10 | 40d | 76d | finish no earlier than 2006-05-10 |
| 125 | 1.5.1.3.2 | Ravna sterha |  | 30d | 2006-04-16 | 2006-05-15 | 2006-04-16 | 2006-05-15 | 30d | 71d | finish no earlier than 2006-05-15 |
| 126 | 1.5.1.3.3 | Toplotna izolacija |  | 21d | 2006-04-05 | 2006-04-25 | 2006-04-05 | 2006-04-25 | 21d | 91d | finish no earlier than 2006-04-25 |
| 127 | 1.5.1.4 | JEKLENA KONSTRUKCIJA |  | 81d | 2006-04-01 | 2006-06-20 | 2006-04-01 | 2006-06-20 | 81d | 35d | finish no earlier than 2006-06-20 |
| 128 | 1.5.2 | **obrtniška dela** |  | 70d | 2006-04-18 | 2006-06-26 | 2006-04-18 | 2006-06-26 | 70d | 29d |  |
| 129 | 1.5.2.1 | KROVSKO KLEPARSKA DELA |  | 50d | 2006-04-22 | 2006-06-10 | 2006-04-22 | 2006-06-10 | 50d | 45d | start no earlier than 2006-04-22 |
| 130 | 1.5.2.2 | ALUMINIJ IN STEKLARSKA DELA |  | 45d | 2006-05-08 | 2006-06-21 | 2006-05-08 | 2006-06-21 | 45d | 34d | start no earlier than 2006-05-08 |
| 131 | 1.5.2.3 | PLESKARSKA DELA - FASADA |  | 70d | 2006-04-18 | 2006-06-26 | 2006-04-18 | 2006-06-26 | 70d | 29d | finish no earlier than 2006-06-26 |
| 132 | 1.5.3 | Elektro inštalacije |  | 30d | 2006-05-28 | 2006-06-26 | 2006-05-28 | 2006-06-26 | 30d | 29d | finish no earlier than 2006-06-26 |
| 133 | 1.5.4 | Tehnični pregled | milestone | 0d | 2006-06-26 | 2006-06-26 | 2006-06-26 | 2006-06-26 | 0d | 30d | start no earlier than 2006-06-26 |
| 134 | 1.5.5 | Uporabno dovoljenje | milestone | 0d | 2006-07-26 | 2006-07-26 | 2006-07-26 | 2006-07-26 | 0d | 0d | start no earlier than 2006-07-26 |
